# Gantt-Task allocation 15-06-18

Schedule from MS Project, 2018-02-26 to 2018-06-25, status date 2018-06-15, costs in €, A marks actual dates.

## Calendars

- Padrão: Mon-Fri 08:00-12:00, 13:00-17:00; Sat-Sun off. Exceptions (off unless hours are given): 2018-03-25 to 2018-04-02 (Easter Holidays), 2018-05-06 to 2018-05-12 (Students week).
- Standard: Mon-Fri 08:00-12:00, 13:00-17:00; Sat-Sun off.

## Resources

| Resource | Rate | Cost per use |
| --- | --- | --- |
| Marta Majewska | 7.5 |  |
| Melanie Tscholl | 7.5 |  |
| Sven Bergervoet | 7.5 |  |
| Cristopher Mahon | 7.5 |  |
| Manuel Baptista | 7.5 |  |
| Wood beam 44*44*2600 |  | 10.98 |
| Wood Bar |  | 1.69 |
| Bearing 8mm interior |  | 2.7 |
| Bearing 10mm interior |  | 5.6 |
| Wood Glue |  | 1.59 |
| Transmission Belt |  | 10 |
| Pulley |  | 17.4 |
| MDF panel 1200*600*10mm |  | 4.99 |
| Arduino UNO |  |  |
| RTC DS1307 |  | 4.7 |
| DC Motor |  |  |
| L298 H Bridge |  | 8.85 |
| HC-05 Bluetooth Receiver |  | 8.3 |
| Logic-Level Translator |  | 2.5 |
| Proximity sensor |  | 5.9 |
| Switch |  | 0.95 |
| 10 kΩ Resistor |  |  |
| Breadboard |  |  |
| 12 V Power Supply |  |  |
| Cloth |  |  |
| Transportation costs from RepRap |  | 4.95 |

## Schedule

| ID | WBS | Task | Type | Duration | Start | Finish | Predecessors | Complete | Remaining | Baseline start | Baseline duration | Total slack | Constraint | Resources | Work | Actual work | Cost | Actual cost |
| --- | --- | --- | --- | --- | --- | --- | --- | --- | --- | --- | --- | --- | --- | --- | --- | --- | --- | --- |
| 1 | 1 | **Outdoor Intelligent Shader** |  | 75d | 2018-02-26 A | 2018-06-25 |  | 95% | 3.38d | 2018-02-26 | 73d | 0d |  |  | 2176h | 1936h | 16,528.45 | 14,728.45 |
| 2 | 1.1 | **Analysing** |  | 3d | 2018-02-26 A | 2018-02-28 A |  | 100% |  | 2018-02-26 | 3d |  |  |  | 40h | 40h | 300 | 300 |
| 3 | 1.1.1 | **Planning** |  | 3d | 2018-02-26 A | 2018-02-28 A |  | 100% |  | 2018-02-26 | 3d |  |  |  | 40h | 40h | 300 | 300 |
| 4 | 1.1.1.1 | Problem |  | 1d | 2018-02-26 A | 2018-02-26 A |  | 100% |  | 2018-02-26 | 1d |  |  | Sven Bergervoet | 8h | 8h | 60 | 60 |
| 5 | 1.1.1.2 | **Target Audience** |  | 1d | 2018-02-26 A | 2018-02-26 A |  | 100% |  | 2018-02-26 | 1d |  |  |  | 8h | 8h | 60 | 60 |
| 6 | 1.1.1.2.1 | Research User |  | 1d | 2018-02-26 A | 2018-02-26 A |  | 100% |  | 2018-02-26 | 1d |  |  | Melanie Tscholl | 8h | 8h | 60 | 60 |
| 7 | 1.1.1.3 | Existing Products |  | 1d | 2018-02-27 A | 2018-02-27 A | 5 | 100% |  | 2018-02-27 | 1d |  |  | Manuel Baptista | 8h | 8h | 60 | 60 |
| 8 | 1.1.1.4 | **Economical Analisys** |  | 1d | 2018-02-27 A | 2018-02-27 A | 7SS | 100% |  | 2018-02-27 | 1d |  |  |  | 8h | 8h | 60 | 60 |
| 9 | 1.1.1.4.1 | SWOT |  | 1d | 2018-02-27 A | 2018-02-27 A |  | 100% |  | 2018-02-27 | 1d |  |  | Marta Majewska | 8h | 8h | 60 | 60 |
| 10 | 1.1.1.5 | Requirements |  | 1d | 2018-02-28 A | 2018-02-28 A | 7 | 100% |  | 2018-02-28 | 1d |  |  | Cristopher Mahon | 8h | 8h | 60 | 60 |
| 11 | 1.2 | **Ideation** |  | 3d | 2018-03-01 A | 2018-03-05 A | 2 | 100% |  | 2018-03-01 | 3d |  |  |  | 48h | 48h | 360 | 360 |
| 12 | 1.2.1 | **Analysing** |  | 3d | 2018-03-01 A | 2018-03-05 A |  | 100% |  | 2018-03-01 | 3d |  |  |  | 48h | 48h | 360 | 360 |
| 13 | 1.2.1.1 | **Product View** |  | 1d | 2018-03-01 A | 2018-03-01 A |  | 100% |  | 2018-03-01 | 1d |  |  |  | 24h | 24h | 180 | 180 |
| 14 | 1.2.1.1.1 | Intentions |  | 1d | 2018-03-01 A | 2018-03-01 A |  | 100% |  | 2018-03-01 | 1d |  |  | Manuel Baptista | 8h | 8h | 60 | 60 |
| 15 | 1.2.1.1.2 | Perception |  | 1d | 2018-03-01 A | 2018-03-01 A |  | 100% |  | 2018-03-01 | 1d |  |  | Cristopher Mahon | 8h | 8h | 60 | 60 |
| 16 | 1.2.1.1.3 | Aesthetics |  | 1d | 2018-03-01 A | 2018-03-01 A |  | 100% |  | 2018-03-01 | 1d |  |  | Marta Majewska | 8h | 8h | 60 | 60 |
| 17 | 1.2.1.2 | Product Ideas(20-40 ideas) |  | 1d | 2018-03-01 A | 2018-03-01 A | 13SS | 100% |  | 2018-03-01 | 1d |  |  | Sven Bergervoet | 8h | 8h | 60 | 60 |
| 18 | 1.2.1.3 | 10 improved ideas |  | 1d | 2018-03-02 A | 2018-03-02 A | 17 | 100% |  | 2018-03-02 | 1d |  |  | Sven Bergervoet | 8h | 8h | 60 | 60 |
| 19 | 1.2.1.4 | Morfological Research |  | 1d | 2018-03-05 A | 2018-03-05 A | 18 | 100% |  | 2018-03-05 | 1d |  |  | Melanie Tscholl | 8h | 8h | 60 | 60 |
| 20 | 1.2.1.5 | Gantt chart | milestone | 0d | 2018-03-05 A | 2018-03-05 A |  | 100% |  | 2018-03-05 | 0d |  | start no earlier than 2018-03-05 | Cristopher Mahon; Manuel Baptista; Marta Majewska; Melanie Tscholl; Sven Bergervoet |  |  |  |  |
| 21 | 1.2.1.6 | Task identification | milestone | 0d | 2018-03-05 A | 2018-03-05 A |  | 100% |  | 2018-03-05 | 0d |  | start no earlier than 2018-03-05 | Cristopher Mahon; Manuel Baptista; Marta Majewska; Melanie Tscholl; Sven Bergervoet |  |  |  |  |
| 22 | 1.2.1.7 | Task allocation | milestone | 0d | 2018-03-05 A | 2018-03-05 A |  | 100% |  | 2018-03-05 | 0d |  | start no earlier than 2018-03-05 | Cristopher Mahon; Manuel Baptista; Marta Majewska; Melanie Tscholl; Sven Bergervoet |  |  |  |  |
| 23 | 1.3 | **Concept** |  | 31d | 2018-03-06 A | 2018-04-25 A | 11 | 100% |  | 2018-03-06 | 29d |  |  |  | 376h | 376h | 2,820 | 2,820 |
| 24 | 1.3.1 | **Analysing** |  | 31d | 2018-03-06 A | 2018-04-25 A |  | 100% |  | 2018-03-06 | 29d |  |  |  | 376h | 376h | 2,820 | 2,820 |
| 25 | 1.3.1.1 | 3 concepts |  | 1d | 2018-03-06 A | 2018-03-06 A |  | 100% |  | 2018-03-06 | 1d |  |  | Sven Bergervoet | 8h | 8h | 60 | 60 |

| ID | WBS | Task | Type | Duration | Start | Finish | Predecessors | Complete | Baseline start | Baseline duration | Constraint | Calendar | Resources | Work | Actual work | Cost | Actual cost |
| --- | --- | --- | --- | --- | --- | --- | --- | --- | --- | --- | --- | --- | --- | --- | --- | --- | --- |
| 26 | 1.3.1.2 | **Final Concept** |  | 30d | 2018-03-07 A | 2018-04-25 A | 25 | 100% | 2018-03-07 | 28d |  |  |  | 368h | 368h | 2,760 | 2,760 |
| 27 | 1.3.1.2.1 | Black Box, structural drafts |  | 4d | 2018-03-07 A | 2018-03-12 A |  | 100% | 2018-03-07 | 4d |  |  | Cristopher Mahon; Melanie Tscholl | 64h | 64h | 480 | 480 |
| 28 | 1.3.1.2.2 | Upload black Box, structural drafts | milestone | 0d | 2018-03-12 A | 2018-03-12 A | 27 | 100% | 2018-03-12 | 0d |  |  | Cristopher Mahon; Melanie Tscholl |  |  |  |  |
| 29 | 1.3.1.2.3 | Detailed schematics, structural drawings,cardboard model |  | 15d | 2018-03-13 A | 2018-04-02 A | 27 | 100% | 2018-03-13 | 9d |  | Standard | Cristopher Mahon; Manuel Baptista; Marta Majewska; Melanie Tscholl; Sven Bergervoet | 40h | 40h | 300 | 300 |
| 30 | 1.3.1.2.4 | Upload Detailed schematics, structural drawings,cardboard model | milestone | 0d | 2018-04-02 A | 2018-04-02 A | 29 | 100% | 2018-03-23 | 0d | finish no earlier than 2018-04-02 |  | Cristopher Mahon; Manuel Baptista; Marta Majewska; Melanie Tscholl; Sven Bergervoet |  |  |  |  |
| 31 | 1.3.1.2.5 | Choosing materials |  | 4d | 2018-04-03 A | 2018-04-06 A | 29 | 100% | 2018-04-03 | 2d |  |  | Cristopher Mahon; Manuel Baptista; Marta Majewska; Melanie Tscholl; Sven Bergervoet | 160h | 160h | 1,200 | 1,200 |
| 32 | 1.3.1.2.6 | Upload selection of materials and components | milestone | 0d | 2018-04-04 A | 2018-04-04 A | 31 | 100% | 2018-04-04 | 0d |  |  | Cristopher Mahon; Manuel Baptista; Marta Majewska; Melanie Tscholl; Sven Bergervoet |  |  |  |  |
| 33 | 1.3.1.2.7 | Search local providers |  | 13d | 2018-04-09 A | 2018-04-25 A | 31 | 100% | 2018-04-05 | 13d |  |  | Manuel Baptista [50%]; Melanie Tscholl [50%] | 104h | 104h | 780 | 780 |
| 34 | 1.3.1.2.8 | Upload selection of local providers and final list of materials and components | milestone | 0d | 2018-04-25 A | 2018-04-25 A | 33 | 100% | 2018-04-23 | 0d |  |  | Cristopher Mahon; Manuel Baptista; Marta Majewska; Melanie Tscholl; Sven Bergervoet |  |  |  |  |
| 35 | 1.4 | **Interim Presentation** |  | 11d | 2018-04-05 A | 2018-04-19 A | 32 | 100% | 2018-04-05 | 11d |  |  |  | 352h | 352h | 2,640 | 2,640 |
| 36 | 1.4.1 | **Planning** |  | 11d | 2018-04-05 A | 2018-04-19 A |  | 100% | 2018-04-05 | 11d |  |  |  | 352h | 352h | 2,640 | 2,640 |
| 37 | 1.4.1.1 | Evaluation meetings |  | 11d | 2018-04-05 A | 2018-04-19 A |  | 100% | 2018-04-05 | 11d |  |  | Melanie Tscholl [50%]; Cristopher Mahon; Manuel Baptista [50%]; Marta Majewska; Sven Bergervoet | 352h | 352h | 2,640 | 2,640 |
| 38 | 1.4.1.2 | Upload deliverables | milestone | 0d | 2018-04-14 A | 2018-04-14 A |  | 100% | 2018-04-14 | 0d | start no earlier than 2018-04-14 |  | Melanie Tscholl; Cristopher Mahon; Manuel Baptista; Marta Majewska; Sven Bergervoet |  |  |  |  |
| 39 | 1.4.1.3 | Presentation | milestone | 0d | 2018-04-19 A | 2018-04-19 A | 37 | 100% | 2018-04-19 | 0d |  |  | Melanie Tscholl; Cristopher Mahon; Manuel Baptista; Marta Majewska; Sven Bergervoet |  |  |  |  |
| 40 | 1.5 | **Construction** |  | 14d | 2018-04-26 A | 2018-05-22 A | 23 | 100% | 2018-04-24 | 14d |  |  |  | 400h | 400h | 3,177.25 | 3,177.25 |
| 41 | 1.5.1 | **Planning** |  | 14d | 2018-04-26 A | 2018-05-22 A |  | 100% | 2018-04-24 | 14d |  |  |  | 400h | 400h | 3,177.25 | 3,177.25 |
| 42 | 1.5.1.1 | **Hardware** |  | 14d | 2018-04-26 A | 2018-05-22 A |  | 100% | 2018-04-24 | 14d |  |  |  | 208h | 208h | 1,674.85 | 1,674.85 |
| 43 | 1.5.1.1.1 | Process material matrix |  | 1d | 2018-04-26 A | 2018-04-26 A |  | 100% | 2018-04-24 | 1d |  |  | Manuel Baptista | 8h | 8h | 60 | 60 |
| 44 | 1.5.1.1.2 | **Materials** |  | 1d | 2018-04-27 A | 2018-04-27 A | 43 | 100% | 2018-04-25 | 1d |  |  |  | 8h | 8h | 60 | 60 |
| 45 | 1.5.1.1.2.1 | Sustainability |  | 1d | 2018-04-27 A | 2018-04-27 A |  | 100% | 2018-04-25 | 1d |  |  | Sven Bergervoet | 8h | 8h | 60 | 60 |
| 46 | 1.5.1.1.3 | **Processes** |  | 12d | 2018-04-30 A | 2018-05-22 A | 44 | 100% | 2018-04-26 | 12d |  |  |  | 192h | 192h | 1,554.85 | 1,554.85 |
| 47 | 1.5.1.1.3.1 | Shaping |  | 12d | 2018-04-30 A | 2018-05-22 A |  | 100% | 2018-04-26 | 12d |  |  | Sven Bergervoet; Bearing 8mm interior; Bearing 10mm interior; Cloth; MDF panel 1200*600*10mm; Pulley; Transmission Belt; Transportation costs from RepRap; Wood Bar; Wood beam 44*44*2600; Wood Glue | 96h | 96h | 779.9 | 779.9 |
| 48 | 1.5.1.1.3.2 | Joining |  | 12d | 2018-04-30 A | 2018-05-22 A |  | 100% | 2018-04-26 | 12d |  |  | Manuel Baptista; Bearing 8mm interior; Bearing 10mm interior; Cloth; MDF panel 1200*600*10mm; Pulley; Transmission Belt; Wood Bar; Wood beam 44*44*2600; Wood Glue | 96h | 96h | 774.95 | 774.95 |
| 49 | 1.5.1.2 | **Software** |  | 12d | 2018-04-30 A | 2018-05-22 A | 46SS | 100% | 2018-04-26 | 12d |  |  |  | 192h | 192h | 1,502.4 | 1,502.4 |
| 50 | 1.5.1.2.1 | Materials |  | 12d | 2018-04-30 A | 2018-05-22 A |  | 100% | 2018-04-26 | 12d |  |  | Cristopher Mahon; 10 kΩ Resistor; 12 V Power Supply; Arduino UNO; Breadboard; DC Motor; HC-05 Bluetooth Receiver; L298 H Bridge; Logic-Level Translator; Proximity sensor [200%]; RTC DS1307; Switch | 96h | 96h | 751.2 | 751.2 |
| 51 | 1.5.1.2.2 | Specifics |  | 12d | 2018-04-30 A | 2018-05-22 A |  | 100% | 2018-04-26 | 12d |  |  | Melanie Tscholl; 10 kΩ Resistor; 12 V Power Supply; Arduino UNO; Breadboard; DC Motor; HC-05 Bluetooth Receiver; L298 H Bridge; Logic-Level Translator; Proximity sensor [200%]; RTC DS1307; Switch | 96h | 96h | 751.2 | 751.2 |
| 52 | 1.5.1.3 | Upload refined report | milestone | 0d | 2018-05-02 A | 2018-05-02 A |  | 100% | 2018-05-02 | 0d | start no earlier than 2018-05-02 |  | Cristopher Mahon; Manuel Baptista; Marta Majewska; Melanie Tscholl; Sven Bergervoet |  |  |  |  |

| ID | WBS | Task | Type | Duration | Start | Finish | Predecessors | Complete | Remaining | Baseline start | Baseline duration | Total slack | Resources | Work | Actual work | Cost | Actual cost |
| --- | --- | --- | --- | --- | --- | --- | --- | --- | --- | --- | --- | --- | --- | --- | --- | --- | --- |
| 53 | 1.6 | **Testing** |  | 11d | 2018-05-23 A | 2018-06-06 A | 40 | 100% |  | 2018-05-21 | 11d |  |  | 440h | 440h | 3,331.2 | 3,331.2 |
| 54 | 1.6.1 | Component tests |  | 11d | 2018-05-23 A | 2018-06-06 A |  | 100% |  | 2018-05-21 | 11d |  | Cristopher Mahon; Manuel Baptista; Marta Majewska; Melanie Tscholl; Sven Bergervoet; 10 kΩ Resistor; 12 V Power Supply; Arduino UNO; Breadboard; DC Motor; HC-05 Bluetooth Receiver; L298 H Bridge; Logic-Level Translator; Proximity sensor; RTC DS1307; Switch | 440h | 440h | 3,331.2 | 3,331.2 |
| 55 | 1.6.2 | Upload functional tests | milestone | 0d | 2018-06-06 A | 2018-06-06 A | 54 | 100% |  | 2018-06-04 | 0d |  | Cristopher Mahon; Melanie Tscholl |  |  |  |  |
| 56 | 1.7 | **Report** |  | 10d | 2018-06-07 A | 2018-06-20 | 53 | 70% | 3d | 2018-06-05 | 10d | 0d |  | 400h | 280h | 3,000 | 2,100 |
| 57 | 1.7.1 | Write final report |  | 10d | 2018-06-07 A | 2018-06-20 |  | 70% | 3d | 2018-06-05 | 10d | 0d | Cristopher Mahon; Manuel Baptista; Marta Majewska; Melanie Tscholl; Sven Bergervoet | 400h | 280h | 3,000 | 2,100 |
| 58 | 1.7.2 | Upload final report | milestone | 0d | 2018-06-20 | 2018-06-20 | 57 |  |  | 2018-06-18 | 0d | 0d | Cristopher Mahon; Manuel Baptista; Marta Majewska; Melanie Tscholl; Sven Bergervoet |  |  |  |  |
| 59 | 1.7.3 | Upload Deliverables | milestone | 0d | 2018-06-20 | 2018-06-20 | 57 |  |  | 2018-06-18 | 0d | 0d | Cristopher Mahon; Manuel Baptista; Marta Majewska; Melanie Tscholl; Sven Bergervoet |  |  |  |  |
| 60 | 1.8 | **Final Presentation** |  | 3d | 2018-06-21 | 2018-06-25 | 56 |  |  | 2018-06-19 | 3d | 0d |  | 120h |  | 900 |  |
| 61 | 1.8.1 | Evaluation meetings |  | 3d | 2018-06-21 | 2018-06-25 |  |  |  | 2018-06-19 | 3d | 0d | Cristopher Mahon; Manuel Baptista; Marta Majewska; Melanie Tscholl; Sven Bergervoet | 120h |  | 900 |  |
| 62 | 1.8.2 | Presentation | milestone | 0d | 2018-06-25 | 2018-06-25 | 61 |  |  | 2018-06-21 | 0d | 0d | Cristopher Mahon; Manuel Baptista; Marta Majewska; Melanie Tscholl; Sven Bergervoet |  |  |  |  |
